# Planning Cuisine provisoire

Schedule from GanttProject, 2024-06-18 to 2026-10-30.

## Calendars

- Project calendar: Mon-Fri working; Sat-Sun off.

## Schedule

| ID | WBS | Task | Duration | Start | Finish | Predecessors |
| --- | --- | --- | --- | --- | --- | --- |
| 1 | 1 | NOTIFICATION DU MARCHE | 9d | 2024-06-18 | 2024-06-28 |  |
| 2 | 2 | **PHASE 1** | 67d | 2024-07-01 | 2024-10-01 | 1 |
| 3 | 2.1 | 1.1 PRÉPARATION ET ÉTUDES | 45d | 2024-07-01 | 2024-08-30 |  |
| 4 | 2.2 | **1.2 INSTALLATION CP, EQUIPEMENTS ET LIGNE SELF N°1** | 22d | 2024-09-02 | 2024-10-01 | 3 |
| 5 | 2.2.1 | INSTALLATION | 18d | 2024-09-02 | 2024-09-25 |  |
| 6 | 2.2.2 | ETAT DES LIEUX ENTREE | 1d | 2024-09-26 | 2024-09-26 |  |
| 7 | 2.2.3 | MISE EN SERVICE | 1d | 2024-10-01 | 2024-10-01 |  |
| 8 | 3 | **PHASE 2** | 521d | 2024-10-02 | 2026-09-30 | 7 |
| 9 | 3.1 | 2.1 LOCATION CP ET ÉQUIPEMENTS | 521d | 2024-10-02 | 2026-09-30 |  |
| 10 | 3.2 | 2.2 MAINTENANCE / SAV CP ET ÉQUIPEMENTS | 521d | 2024-10-02 | 2026-09-30 |  |
| 11 | 3.3 | 2.3 LOCATION LIGNE SELF N°1 | 521d | 2024-10-02 | 2026-09-30 |  |
| 12 | 3.4 | 2.4 MAINTENANCE / SAV LIGNE SELF N°1 | 521d | 2024-10-02 | 2026-09-30 |  |
| 13 | 3.5 | **2.5 INSTALLATION LIGNE SELF N°2** | 8d | 2025-09-22 | 2025-10-01 |  |
| 14 | 3.5.1 | INSTALLATION | 6d | 2025-09-22 | 2025-09-29 |  |
| 15 | 3.5.2 | ETAT DES LIEUX | 1d | 2025-09-30 | 2025-09-30 | 14 |
| 16 | 3.5.3 | MISE EN SERVICE | 1d | 2025-10-01 | 2025-10-01 | 15 |
| 17 | 3.6 | 2.5 LOCATION LIGNE SELF N°2 | 260d | 2025-10-02 | 2026-09-30 | 16 |
| 18 | 3.7 | 2.6 MAINTENANCE / SAV LIGNE SELF N°2 | 260d | 2025-10-02 | 2026-09-30 |  |
| 19 | 4 | **PHASE 3** | 22d | 2026-10-01 | 2026-10-30 | 8 |
| 20 | 4.1 | ETAT DES LIEUX SORTIE | 1d | 2026-10-01 | 2026-10-01 |  |
| 21 | 4.2 | ENLÈVEMENT ET REMISE EN ÉTAT DU SITE | 21d | 2026-10-02 | 2026-10-30 | 20 |
| 22 | 5 | CP = CUISINE PROVISOIRE | 1d | 2024-06-18 | 2024-06-18 |  |
